# Cronoprogramma_periziavariante_rev2

Schedule from MS Project, 2014-11-03 to 2015-02-05.
Sidercad s.p.a.

## Calendars

- Standard: Mon-Sun 09:00-13:00, 14:00-18:00.

## Schedule

| ID | WBS | Task | Duration | Start | Finish | Predecessors | Total slack | Free slack | Constraint |
| --- | --- | --- | --- | --- | --- | --- | --- | --- | --- |
| 1 | 1 | **LOTTO 1.03 - FASE FINALE LAVORI** | 95d | 2014-11-03 | 2015-02-05 |  | 0d |  |  |
| 2 | YA.1.E.03.01 | **Ripresa attività** | 11d | 2014-11-03 | 2014-11-13 |  | 0d |  |  |
| 3 | YA.1.E.03.01.01 | Consegna perizia variante - verbale ripresa lavori | 1d | 2014-11-03 | 2014-11-03 |  | 0d |  | start no earlier than 2014-11-03 |
| 4 | YA.1.E.03.01.02 | Adempimenti conseguenti | 10d | 2014-11-04 | 2014-11-13 | 3 | 1d | 0d |  |
| 5 | YA.1.E.03.02 | **Opere piazzale (separato appalto)** | 37d | 2014-11-14 | 2014-12-20 | 2 | 1d |  |  |
| 6 | 1.2.1 | Organizzazione e adempimenti | 10d | 2014-11-14 | 2014-11-23 |  | 1d | 0d |  |
| 7 | 1.2.2 | Prima fase scarifica e livellamento | 2d | 2014-11-24 | 2014-11-25 | 6 | 1d | 0d |  |
| 8 | 1.2.3 | Realizzazione caditoie nuove | 4d | 2014-11-26 | 2014-11-29 | 7 | 63d | 0d | finish no earlier than 2014-02-26 |
| 9 | 1.2.4 | Ricariche e pavimentazione finale | 5d | 2014-12-16 | 2014-12-20 | 8, 25, 18 | 47d |  | start no earlier than 2014-02-27 |
| 10 | YA.1.E.03.03 | **Rinterri a perimetro del fabbricato Piattaforma** | 27d | 2014-11-14 | 2014-12-10 |  | 35d | 0d |  |
| 11 | YA.1.E.03.03.01 | preparazione e verifiche tubazioni | 2d | 2014-11-14 | 2014-11-15 | 4 | 35d | 0d |  |
| 12 | 1.3.2 | realizzazione bauletti protezione tubazioni | 10d | 2014-11-16 | 2014-11-25 | 11 | 35d | 0d |  |
| 13 | YA.1.E.03.03.02 | esecuzione riempimenti | 10d | 2014-11-26 | 2014-12-05 | 12 | 35d | 0d |  |
| 14 | YA.1.E.03.03.03 | esecuzione magrone | 2d | 2014-11-21 | 2014-11-22 | 13FS-15d | 35d | 0d |  |
| 15 | 1.3.5 | maturazione | 5d | 2014-11-23 | 2014-11-27 | 14 | 49d | 0d |  |
| 16 | 1.3.6 | realizzazione pavimentazione industriale | 3d | 2014-11-28 | 2014-11-30 | 15 | 49d | 0d |  |
| 17 | 1.3.7 | maturazione, giunti e finiture varie | 7d | 2014-12-01 | 2014-12-07 | 16 | 49d | 0d |  |
| 18 | 1.3.8 | realizzazione pavimentazioni bituminose a perimetro | 3d | 2014-12-08 | 2014-12-10 | 17 | 49d | 0d |  |
| 19 | 1.4 | **Cabina MT/BT** | 80d | 2014-11-04 | 2015-01-22 |  | 0d |  |  |
| 20 | 1.4.1 | approvvigionamento prefabbricato | 30d | 2014-11-04 | 2014-12-03 | 3 | 0d |  |  |
| 21 | 1.4.2 | scavo fondazione cabina e getto magrone | 4d | 2014-11-26 | 2014-11-29 | 7 | 1d | 0d |  |
| 22 | 1.4.3 | realizzazione fondazione cabina e maturazione | 3d | 2014-11-30 | 2014-12-02 | 21 | 1d |  |  |
| 23 | 1.4.4 | montaggio struttura cabina | 2d | 2014-12-04 | 2014-12-05 | 20, 22 | 0d |  |  |
| 24 | 1.4.5 | demolizione muro perimetrale e rifacimento in posizione traslata | 7d | 2014-12-06 | 2014-12-12 | 23 | 52d | 0d |  |
| 25 | 1.4.6 | scavi preparatori area esterna antistante | 3d | 2014-12-13 | 2014-12-15 | 24 | 52d |  |  |
| 26 | 1.4.7 | realizzazione della pavimentazione interna e dei completamenti civili | 5d | 2015-01-10 | 2015-01-14 | 31 | 0d |  |  |
| 27 | 1.4.8 | realizzazione degli impianti elettrici | 5d | 2015-01-15 | 2015-01-19 | 26 | 14d | 0d |  |
| 28 | 1.4.9 | riempimenti e completamenti rea esterna | 3d | 2015-01-20 | 2015-01-22 | 27 | 14d |  |  |

| ID | WBS | Task | Duration | Start | Finish | Predecessors | Total slack | Free slack |
| --- | --- | --- | --- | --- | --- | --- | --- | --- |
| 29 | 1.5 | **Cabina MT/BT - allestimenti A2A** | 55d | 2014-12-06 | 2015-01-29 |  | 0d |  |
| 30 | 1.5.1 | comunicazione disponibilità / sopralluogo | 30d | 2014-12-06 | 2015-01-04 | 23 | 0d |  |
| 31 | 1.5.2 | realizzazione allestimenti di prima fase | 5d | 2015-01-05 | 2015-01-09 | 30 | 0d |  |
| 32 | 1.5.3 | installazione apparati ed opere di completamento | 15d | 2015-01-15 | 2015-01-29 | 26 | 0d |  |
| 33 | 1.6 | **Opere area deposito Bombole e sistemazioni esterne** | 32d | 2014-11-14 | 2014-12-15 |  | 52d |  |
| 34 | 1.6.1 | preparazione area deposito bombole | 5d | 2014-11-14 | 2014-11-18 | 4 | 54d | 0d |
| 35 | 1.6.2 | realizzazione strutture deposito bombole | 15d | 2014-11-24 | 2014-12-08 | 34FS+5d | 54d | 2d |
| 36 | 1.6.3 | sistemazioni stradali e delle aree esterne | 5d | 2014-12-11 | 2014-12-15 | 35, 10 | 52d |  |
| 37 | 1.7 | **Completamento opere edili Piattaforma** | 40d | 2014-11-23 | 2015-01-01 | 14 | 35d |  |
| 38 | 1.7.1 | completamenti pareti in pannelli | 5d | 2014-11-23 | 2014-11-27 |  | 35d | 0d |
| 39 | 1.7.2 | realizzazione pavimenti interni | 10d | 2014-11-28 | 2014-12-07 | 38 | 35d | 0d |
| 40 | 1.7.3 | installazione serramenti | 15d | 2014-12-08 | 2014-12-22 | 39 | 35d | 0d |
| 41 | 1.7.4 | finiture varie | 10d | 2014-12-23 | 2015-01-01 | 40 | 35d |  |
| 42 | 1.8 | **Impianti idrico - sanitari** | 30d | 2014-11-23 | 2014-12-22 |  | 45d |  |
| 43 | 1.8.1 | completamento pluviali e fognature | 10d | 2014-11-23 | 2014-12-02 | 14 | 45d | 0d |
| 44 | 1.8.2 | allestimenti area servizi igienici | 10d | 2014-12-03 | 2014-12-12 | 43 | 45d | 0d |
| 45 | 1.8.3 | allestimenti area locali lavorazione e celle | 10d | 2014-12-13 | 2014-12-22 | 44 | 45d |  |
| 46 | 1.8.4 | completamenti impianto antincendio | 5d | 2014-12-03 | 2014-12-07 | 43 | 60d |  |
| 47 | YA.1.E.03.04 | **Impianti elettrici** | 24d | 2014-11-23 | 2014-12-16 |  | 44d |  |
| 48 | 1.9.1 | posa canale distribuzione generale | 6d | 2014-11-23 | 2014-11-28 | 14 | 44d | 0d |
| 49 | YA.1.E.03.04.01 | completamento quadri e allestimenti | 10d | 2014-11-29 | 2014-12-08 | 48 | 44d | 0d |
| 50 | 1.9.3 | impianto illuminazione interna | 8d | 2014-12-09 | 2014-12-16 | 49 | 44d |  |
| 51 | 1.9.4 | impianto illuminazione esterna | 7d | 2014-12-09 | 2014-12-15 | 49 | 45d |  |
| 52 | 1.9.5 | collegamenti cabina - utenze | 8d | 2014-12-09 | 2014-12-16 | 49 | 44d |  |

| ID | WBS | Task | Type | Duration | Start | Finish | Predecessors | Total slack |
| --- | --- | --- | --- | --- | --- | --- | --- | --- |
| 53 | YA.1.E.03.05 | **Sistemazioni e completamenti** |  | 7d | 2015-01-30 | 2015-02-05 |  | 0d |
| 54 | 1.10.1 | Collaudi e verifiche |  | 4d | 2015-01-30 | 2015-02-02 | 47, 29 | 0d |
| 55 | 1.10.2 | smantellamento cantiere |  | 2d | 2015-02-03 | 2015-02-04 | 54 | 0d |
| 56 | 1.10.3 | termine lavori | milestone | 1d | 2015-02-05 | 2015-02-05 | 55 | 0d |
